# LOCALIZATION

Schedule from MS Project, 2012-06-04 to 2012-07-31, costs in €.

## Calendars

- Standard: Mon-Fri 08:00-12:00, 13:00-17:00; Sat-Sun off.

## Resources

| Resource | Rate |
| --- | --- |
| PM | 62.5 |
| TRNR | 43.75 |
| XLTR1 | 60 |
| XLTR2 | 50 |
| XLTR3 | 50 |
| PRDR1 | 30 |
| PRDR2 | 30 |
| PRDR3 | 30 |
| VLDTR | 50 |
| TECH | 56.25 |
| TSTR1 | 43.75 |
| TSTR2 | 43.75 |

## Schedule

| ID | WBS | Task | Type | Duration | Start | Finish | Predecessors | Total slack | Resources | Work | Cost |
| --- | --- | --- | --- | --- | --- | --- | --- | --- | --- | --- | --- |
| 1 | 1 | **LOCALIZATION** |  | 42d | 2012-06-04 | 2012-07-31 |  | 0d |  | 697.6h | 34,910 |
| 2 | 1.1 | PRODUCT TRAINING FOR TRANSLATORS | manual | 2d | 2012-06-04 | 2012-06-05 |  |  | TRNR; XLTR1; XLTR2; XLTR3 | 64h | 3,260 |
| 3 | 1.2 | **PRELIMINARY WORK & TRANSLATIONS, GLOSSARY CREATION, GUIDELINES** |  | 10d | 2012-06-06 | 2012-06-19 |  | 0d |  | 104h | 5,520 |
| 4 | 1.2.1 | Study product UI | manual | 1d | 2012-06-06 | 2012-06-06 | 2 |  | XLTR1 | 8h | 480 |
| 5 | 1.2.2 | Translate Overview document | manual | 2d | 2012-06-07 | 2012-06-08 | 4 |  | XLTR1 | 16h | 960 |
| 6 | 1.2.3 | Proofread Overview document translation | manual | 1d | 2012-06-11 | 2012-06-11 | 5 |  | PRDR1 | 8h | 240 |
| 7 | 1.2.4 | Translate Glossary section of Help | manual | 1d | 2012-06-12 | 2012-06-12 | 6 |  | XLTR1 | 8h | 480 |
| 8 | 1.2.5 | Proofread Glossary section of Help translation | manual | 1d | 2012-06-13 | 2012-06-13 | 7 |  | PRDR1 | 8h | 240 |
| 9 | 1.2.6 | Build bilingual glossary | manual | 2d | 2012-06-14 | 2012-06-15 | 8 |  | XLTR1 | 16h | 960 |
| 10 | 1.2.7 | Write translation guidelines | manual | 1d | 2012-06-18 | 2012-06-18 | 9 |  | XLTR1 | 8h | 480 |
| 11 | 1.2.8 | Discuss, adjust and agree on bilingual glossary and translation guidelines | manual | 1d | 2012-06-19 | 2012-06-19 | 10 |  | VLDTR; XLTR1; XLTR2; XLTR3 | 32h | 1,680 |
| 12 | 1.3 | **UI TRANSLATION** |  | 7d | 2012-06-20 | 2012-06-28 |  | 0d |  | 56h | 2,850 |
| 13 | 1.3.1 | Translate UI | manual | 3d | 2012-06-20 | 2012-06-22 | 11 |  | XLTR1 | 24h | 1,440 |
| 14 | 1.3.2 | Proofread UI translation | manual | 2d | 2012-06-25 | 2012-06-26 | 13 |  | PRDR1 | 16h | 480 |
| 15 | 1.3.3 | Make final adjustments to bilingual glossary | manual | 1d | 2012-06-27 | 2012-06-27 | 14 |  | XLTR1 | 8h | 480 |
| 16 | 1.3.4 | Make product with translated UI available to translators | manual | 1d | 2012-06-28 | 2012-06-28 | 15 |  | TECH | 8h | 450 |
| 17 | 1.4 | **HELP TRANSLATION** |  | 6d | 2012-06-29 | 2012-07-06 |  | 0d |  | 48h | 2,400 |
| 18 | 1.4.1 | Translate (text-only, non-illustrated) Help | manual | 4d | 2012-06-29 | 2012-07-04 | 16 |  | XLTR1 | 32h | 1,920 |
| 19 | 1.4.2 | Proofread Help | manual | 2d | 2012-07-05 | 2012-07-06 | 18 |  | PRDR1 | 16h | 480 |
| 20 | 1.5 | **ADMIN'S GUIDE TRANSLATION** |  | 12d | 2012-06-29 | 2012-07-16 |  | 0d |  | 96h | 4,160 |
| 21 | 1.5.1 | Translate Admin's Guide | manual | 5d | 2012-06-29 | 2012-07-05 | 16 |  | XLTR2 | 40h | 2,000 |
| 22 | 1.5.2 | Make UI screenshots for Admin's Guide | manual | 2d | 2012-07-06 | 2012-07-09 | 21 |  | XLTR2 | 16h | 800 |
| 23 | 1.5.3 | Integrate screenshots into Admin's Guide | manual | 1d | 2012-07-10 | 2012-07-10 | 22 |  | XLTR2 | 8h | 400 |
| 24 | 1.5.4 | Proofread Admin's Guide translation | manual | 4d | 2012-07-11 | 2012-07-16 | 23 |  | PRDR2 | 32h | 960 |

| ID | WBS | Task | Type | Duration | Start | Finish | Predecessors | Total slack | Resources | Work | Cost |
| --- | --- | --- | --- | --- | --- | --- | --- | --- | --- | --- | --- |
| 25 | 1.6 | **USER'S GUIDE TRANSLATION** |  | 12d | 2012-06-29 | 2012-07-16 |  | 0d |  | 96h | 4,160 |
| 26 | 1.6.1 | Translate User's Guide | manual | 5d | 2012-06-29 | 2012-07-05 | 16 |  | XLTR3 | 40h | 2,000 |
| 27 | 1.6.2 | Make UI screenshots for User's Guide | manual | 2d | 2012-07-06 | 2012-07-09 | 26 |  | XLTR3 | 16h | 800 |
| 28 | 1.6.3 | Integrate screenshots into User's Guide | manual | 1d | 2012-07-10 | 2012-07-10 | 27 |  | XLTR3 | 8h | 400 |
| 29 | 1.6.4 | Proofread User's Guide translation | manual | 4d | 2012-07-11 | 2012-07-16 | 28 |  | PRDR3 | 32h | 960 |
| 30 | 1.7 | **TESTING & ACCEPTANCE** |  | 15d | 2012-07-09 | 2012-07-27 |  | 0d |  | 128h | 6,230 |
| 31 | 1.7.1 | Test localized product (UI + Help) | manual | 3d | 2012-07-09 | 2012-07-11 | 19 |  | TSTR1 | 24h | 1,050 |
| 32 | 1.7.2 | Make corrections to UI & Help | manual | 1d | 2012-07-12 | 2012-07-12 | 31 |  | XLTR1 | 8h | 480 |
| 33 | 1.7.3 | Test localized product (Guides) | manual | 6d | 2012-07-17 | 2012-07-24 | 24, 29 |  | TSTR2 | 48h | 2,100 |
| 34 | 1.7.4 | Make corrections to Guides | manual | 1d | 2012-07-25 | 2012-07-25 | 33 |  | XLTR2; XLTR3 | 16h | 800 |
| 35 | 1.7.5 | Accept localized product | manual | 2d | 2012-07-26 | 2012-07-27 | 32, 34 |  | PM; VLDTR | 32h | 1,800 |
| 36 | 1.8 | DEPLOYMENT OF LOCALIZED PRODUCT |  | 1d | 2012-07-30 | 2012-07-30 | 35 | 0d | TECH | 8h | 450 |
| 37 | 1.9 | PROJECT MANAGEMENT | manual | 41d | 2012-06-04 | 2012-07-30 |  |  | PM [20%] | 65.6h | 4,100 |
| 38 | 1.10 | PROJECT CLOSURE |  | 1d | 2012-07-31 | 2012-07-31 | 36 | 0d | PM; XLTR1; XLTR2; XLTR3 | 32h | 1,780 |
